# CANTERAS CHICAMA

Schedule from Primavera P6, 2023-02-09 to 2024-10-15, data date 2023-02-09.

## Calendars

- Dos turnos - 6x1 - 8 horas: Mon-Sat 02:00-06:00, 08:00-12:00, 14:00-18:00, 20:00-00:00; Sun off. Exceptions (off unless hours are given): 2023-04-06 to 2023-04-07, 2023-05-01, 2023-06-29, 2023-07-28 to 2023-07-29, 2023-08-30, 2023-11-01, 2023-12-08, 2023-12-25, 2024-01-01, 2024-03-28 to 2024-03-29, 2024-05-01, 2024-06-29, 2024-07-29, 2024-08-06, 2024-08-30, 2024-10-08.

## Schedule

| ID | WBS | Activity | Type | Duration | Start | Finish | Predecessors | Total float | Free float |
| --- | --- | --- | --- | --- | --- | --- | --- | --- | --- |
|  | 1 | **HITOS** |  |  | 2023-02-09 | 2024-10-15 |  |  |  |
| A1000 |  | Adjudicación | milestone | 0d | 2023-02-09 | 2023-02-09 |  | 0d |  |
| A1010 |  | Suscripción de Subcontrato | milestone | 0d | 2023-02-20 | 2023-02-20 | A1000 FS+9d | 0d |  |
| A1020 |  | Inicio de Servicio - Acceso al Sitio | milestone | 0d | 2023-03-03 | 2023-03-03 | A1010 FS+10d | 0d |  |
| A1030 |  | Autorización para adquisición y almacenamiento de explosivos | milestone | 0d | 2023-03-11 | 2023-03-11 | A1070, A1080, A1090, A1100 | 481d | 21d |
| A1040 |  | Primera Voladura | milestone | 0d | 2023-04-05 | 2023-04-05 | A1030, A1010 FS+38d, A1280 SS+13d, A1410 SS+6d | 460d |  |
| A1050 |  | Entrega de 800,000 m3 de roca seleccionada | milestone | 0d | 2024-01-26 | 2024-01-26 | A1420 SF+237d | 217d |  |
| A1060 |  | Culminación del Servicio | milestone | 0d | 2024-10-15 | 2024-10-15 | A1120, A1040, A1050, A1150 | 0d |  |
|  | 2 | **OBRAS PROVISIONALES** |  |  | 2023-02-20 | 2023-03-11 |  |  |  |
| A1070 |  | Tramite, Gestión y Obtención de permisos para uso y adquisición de explosivos |  | 17d | 2023-02-20 | 2023-03-11 | A1010 | 0d |  |
| A1080 |  | Tramite, Gestión y Obtención de permisos para manipulación de explosivos |  | 17d | 2023-02-20 | 2023-03-11 | A1010 | 0d |  |
| A1090 |  | Tramite, Gestión y Obtención de permisos para almacenamiento y uso de Polvorín |  | 17d | 2023-02-20 | 2023-03-11 | A1010 | 0d |  |
| A1100 |  | Tramite, Gestión y Obtención de permisos para Explotación de Canteras |  | 17d | 2023-02-20 | 2023-03-11 | A1010 | 0d |  |
|  | 3 | **OBRAS PRELIMINARES** |  |  | 2023-03-03 | 2024-10-15 |  |  |  |
|  | 1 | **Movilización y Desmovilización** |  |  | 2023-03-03 | 2024-10-15 |  |  |  |
| A1110 |  | Movilización de equipos a obra |  | 26d | 2023-03-03 | 2023-04-02 | A1020 | 0d |  |
| A1120 |  | Desmovilización de equipos de obra |  | 12d | 2024-09-30 | 2024-10-15 | A1420, A1430, A1460, A1200, A1230, A1260, A1350, A1360, A1540, A1560, A1590, A1600, A1330, A1480, A1490, A1520 | 0d |  |
|  | 2 | **Trazo y replanteo** |  |  | 2023-03-07 | 2024-10-15 |  |  |  |
| A1130 |  | Trazo y replanteo topográfico al inicio de obra |  | 12d | 2023-03-07 | 2023-03-21 | A1110 SS+3d | 0d |  |
| A1140 |  | Control topográfico del material seleccionado |  | 461d | 2023-03-21 | 2024-09-29 | A1130 | 0d |  |
| A1150 |  | Levantamiento Topografico final de obra |  | 12d | 2024-09-30 | 2024-10-15 | A1140 | 0d |  |
|  | 3 | **Construcción y mantenimiento de accesos** |  |  | 2023-03-10 | 2024-09-28 |  |  |  |
| A1170 |  | Excavación en Material Común |  | 95d | 2023-03-10 | 2023-07-04 | A1130 SS+3d | 0d |  |
| A1180 |  | Excavación en roca fracturada |  | 95d | 2023-03-10 | 2023-07-04 | A1170 SS | 0d |  |
| A1190 |  | Excavación en roca fija con martillo hidráulico |  | 144d | 2023-03-14 | 2023-09-06 | A1180 SS+3d | 0d |  |
| A1200 |  | Relleno compactado con equipo pesado para accesos |  | 144d | 2023-03-17 | 2023-09-09 | A1190 SS, A1210 SS | 0d |  |
| A1210 |  | Proceso y selección de material propio |  | 144d | 2023-03-17 | 2023-09-09 | A1170 SS+6d | 0d |  |
| A1230 |  | Mantenimiento de accesos (L = 2km) |  | 463d | 2023-03-17 | 2024-09-28 | A1180 SS+6d | 1d |  |

| ID | WBS | Activity | Duration | Start | Finish | Predecessors | Total float | Free float |
| --- | --- | --- | --- | --- | --- | --- | --- | --- |
|  | 4 | **Construcción de Campamentos** |  | 2023-03-11 | 2024-09-28 |  |  |  |
| A1280 |  | Construcción e Implementación de Polvorin | 26d | 2023-03-11 | 2023-04-13 | A1130 SS+3d, A1070, A1080, A1090, A1100 | 0d |  |
| A1240 |  | Conformación de terraplén para campamentos | 50d | 2023-03-14 | 2023-05-14 | A1180 SS+3d | 1d | 0d |
| A1250 |  | Construcción de campamentos | 50d | 2023-03-17 | 2023-05-18 | A1240 SS+3d | 1d | 0d |
| A1260 |  | Mantenimiento de campamento | 437d | 2023-04-19 | 2024-09-28 | A1250 SS+26d | 1d |  |
|  | 5 | **Conformación de plataforma para zonas de acopio** |  | 2023-03-10 | 2023-12-19 |  |  |  |
| A1300 |  | Excavación en Material Común | 84d | 2023-03-10 | 2023-06-20 | A1170 SS | 0d |  |
| A1310 |  | Relleno compactado con equipo pesado para plataforma de acopio | 210d | 2023-03-24 | 2023-12-03 | A1300 SS+12d | 0d |  |
| A1320 |  | Suministro, construcción e instalación de Cerco perímetrico | 210d | 2023-04-10 | 2023-12-19 | A1310 SS+12d | 236d | 0d |
| A1330 |  | Suministro, construcción e instalación de garita de control de ingreso y salida | 210d | 2023-04-10 | 2023-12-19 | A1320 SS | 236d |  |
|  | 6 | **Seguridad y Medio Ambiente** |  | 2023-03-03 | 2024-09-29 |  |  |  |
| A1340 |  | Señalización de obra | 476d | 2023-03-03 | 2024-09-29 | A1020 | 0d |  |
| A1350 |  | Implementación de controles ambientales durante la construcción | 476d | 2023-03-03 | 2024-09-29 | A1340 SS | 0d |  |
| A1360 |  | Conformación de Material Excedente en DME y DMO | 476d | 2023-03-03 | 2024-09-29 | A1340 SS | 0d |  |
|  | 4 | **EXPLOTACIÓN DE CANTERA** |  | 2023-03-21 | 2024-09-29 |  |  |  |
|  | 1 | **Habilitación de Cantera** |  | 2023-03-21 | 2024-06-29 |  |  |  |
| A1390 |  | Excavación en material común (hasta roca fracturada) | 210d | 2023-03-21 | 2023-11-30 | A1200 SS+3d | 0d |  |
| A1400 |  | Excavación en roca fracturada (hasta roca macizo rocoso) | 210d | 2023-03-21 | 2023-11-30 | A1390 SS | 0d |  |
| A1410 |  | Perforación manual y voladura (habilitación de área de perforación para Rockdrill) | 379d | 2023-03-29 | 2024-06-29 | A1400 SS+7d, A1280 SS+15d | 0d |  |
|  | 2 | **Producción Material en cantera de cerro (macizo rocoso)** |  | 2023-04-14 | 2024-09-29 |  |  |  |
|  | 1 | **Producción - roca de 0.80 - 1.50 m** |  | 2023-04-14 | 2024-09-29 |  |  |  |
| A1420 |  | Nuevo Alto Perú | 441d | 2023-04-14 | 2024-09-28 | A1410 SS+12d, A1310 SS+16d | 0d |  |
| A1430 |  | San Bartolo 01 | 436d | 2023-04-21 | 2024-09-29 | A1420 SS+6d | 0d |  |
| A1460 |  | Oso 02 | 424d | 2023-05-06 | 2024-09-29 | A1430 SS+12d | 0d |  |

| ID | WBS | Activity | Duration | Start | Finish | Predecessors | Total float | Free float |
| --- | --- | --- | --- | --- | --- | --- | --- | --- |
|  | 2 | **Fracturación - roca para gaviones de 0.15 - 0.20 m** |  | 2023-04-14 | 2024-09-29 |  |  |  |
| A1480 |  | Nuevo Alto Perú | 441d | 2023-04-14 | 2024-09-28 | A1420 SS | 0d |  |
| A1490 |  | San Bartolo 01 | 436d | 2023-04-21 | 2024-09-29 | A1430 SS, A1480 SS+6d | 0d |  |
| A1520 |  | Oso 02 | 424d | 2023-05-06 | 2024-09-29 | A1460 SS | 0d |  |
|  | 3 | **Carguio de Material Remanente en acopio para Eliminación** |  | 2023-04-14 | 2024-09-29 |  |  |  |
| A1540 |  | Carguio de Material Remanente en acopio para Eliminación | 442d | 2023-04-14 | 2024-09-29 | A1420 SS | 0d |  |
|  | 3 | **Producción Material en cantera de cauce (boloneria suelta)** |  | 2023-05-24 | 2024-09-07 |  |  |  |
| A1550 |  | Fracturación y selección de Roca con martillo hidráulico | 390d | 2023-05-24 | 2024-09-07 | A1400 SS+52d | 19d | 0d |
| A1560 |  | Carguio de Material Remanente en acopio para Eliminación | 390d | 2023-05-24 | 2024-09-07 | A1550 SS | 19d |  |
|  | 4 | **Carguio de Material acopiado** |  | 2023-04-14 | 2024-09-29 |  |  |  |
| A1570 |  | Carguio de Material acopiado | 442d | 2023-04-14 | 2024-09-29 | A1420 SS | 0d |  |
|  | 5 | **IMPLEMENTACION PARA CONTROL Y PESAJE DE ROCA** |  | 2023-03-21 | 2024-09-29 |  |  |  |
|  | 1 | **Instalación de Sistema de Pesaje** |  | 2023-03-21 | 2024-09-29 |  |  |  |
| A1575 |  | Obras Civiles | 26d | 2023-03-21 | 2023-04-22 | A1190 SS+6d | 0d |  |
| A1580 |  | Instalación de balanza, caseta y tablero de control de Pesaje | 26d | 2023-04-13 | 2023-05-14 | A1575 SS+18d | 0d |  |
| A1590 |  | Operación y control de Sistema de pesaje | 437d | 2023-04-20 | 2024-09-29 | A1580 SS+6d | 0d |  |
|  | 6 | **PRUEBAS DE CONTROL DE CALIDAD** |  | 2023-04-14 | 2024-09-29 |  |  |  |
| A1600 |  | Ensayos de Roca | 442d | 2023-04-14 | 2024-09-29 | A1570 SS | 0d |  |
